| id | name | startDate | endDate | priority | barScale | progress | type | parentId |
| --- | --- | --- | --- | --- | --- | --- | --- | --- |
| 1 | Restaurant Opening | 2026-06-01T00:00:00.000Z | 2026-11-28T00:00:00.000Z | medium | 1 | 0 | group |  |
| 2 | Refine concept | 2026-06-01T00:00:00.000Z | 2026-06-15T00:00:00.000Z | high | 1 | 0 | task | 1 |
| 3 | Negotiate lease | 2026-06-08T00:00:00.000Z | 2026-06-29T00:00:00.000Z | medium | 1 | 0 | task | 1 |
| 4 | Attorney review | 2026-06-22T00:00:00.000Z | 2026-06-29T00:00:00.000Z | medium | 1 | 0 | task | 1 |
| 5 | Engage architect | 2026-06-29T00:00:00.000Z | 2026-07-06T00:00:00.000Z | medium | 1 | 0 | task | 1 |
| 6 | Business license | 2026-06-01T00:00:00.000Z | 2026-06-15T00:00:00.000Z | medium | 1 | 0 | task | 1 |
| 7 | Architectural drawings | 2026-07-06T00:00:00.000Z | 2026-07-27T00:00:00.000Z | medium | 1 | 0 | task | 1 |
| 8 | Submit building permit | 2026-07-27T00:00:00.000Z | 2026-07-28T00:00:00.000Z | high | 1 | 0 | milestone | 1 |
| 9 | Health dept review | 2026-07-27T00:00:00.000Z | 2026-09-25T00:00:00.000Z | medium | 1 | 0 | task | 1 |
| 10 | Fire marshal review | 2026-07-27T00:00:00.000Z | 2026-09-10T00:00:00.000Z | medium | 1 | 0 | task | 1 |
| 11 | Alcohol license app | 2026-07-27T00:00:00.000Z | 2026-10-25T00:00:00.000Z | high | 1 | 0 | task | 1 |
| 12 | Order long-lead equipment | 2026-07-27T00:00:00.000Z | 2026-08-03T00:00:00.000Z | high | 1 | 0 | task | 1 |
| 13 | Demolition | 2026-08-10T00:00:00.000Z | 2026-08-17T00:00:00.000Z | medium | 1 | 0 | task | 1 |
| 14 | MEP rough-in | 2026-08-17T00:00:00.000Z | 2026-08-31T00:00:00.000Z | medium | 1 | 0 | task | 1 |
| 15 | Hood and gas line | 2026-08-20T00:00:00.000Z | 2026-08-30T00:00:00.000Z | high | 1 | 0 | task | 1 |
| 16 | Drywall, paint, floor | 2026-08-31T00:00:00.000Z | 2026-09-21T00:00:00.000Z | medium | 1 | 0 | task | 1 |
| 17 | FOH furniture | 2026-09-21T00:00:00.000Z | 2026-10-05T00:00:00.000Z | medium | 1 | 0 | task | 1 |
| 18 | Kitchen equipment install | 2026-09-29T00:00:00.000Z | 2026-10-13T00:00:00.000Z | medium | 1 | 0 | task | 1 |
| 19 | Final inspection | 2026-10-19T00:00:00.000Z | 2026-10-24T00:00:00.000Z | high | 1 | 0 | milestone | 1 |
| 20 | Develop menu | 2026-08-10T00:00:00.000Z | 2026-09-09T00:00:00.000Z | medium | 1 | 0 | task | 1 |
| 21 | Source distributors | 2026-08-30T00:00:00.000Z | 2026-09-20T00:00:00.000Z | medium | 1 | 0 | task | 1 |
| 22 | Cost every dish | 2026-09-09T00:00:00.000Z | 2026-09-23T00:00:00.000Z | medium | 1 | 0 | task | 1 |
| 23 | Standardize recipes | 2026-09-19T00:00:00.000Z | 2026-10-10T00:00:00.000Z | medium | 1 | 0 | task | 1 |
| 24 | Hire FOH manager | 2026-09-09T00:00:00.000Z | 2026-09-23T00:00:00.000Z | medium | 1 | 0 | task | 1 |
| 25 | Hire kitchen staff | 2026-09-29T00:00:00.000Z | 2026-10-20T00:00:00.000Z | medium | 1 | 0 | task | 1 |
| 26 | Hire FOH staff | 2026-10-14T00:00:00.000Z | 2026-11-04T00:00:00.000Z | medium | 1 | 0 | task | 1 |
| 27 | POS setup and training | 2026-10-19T00:00:00.000Z | 2026-11-02T00:00:00.000Z | medium | 1 | 0 | task | 1 |
| 28 | Service training | 2026-10-29T00:00:00.000Z | 2026-11-12T00:00:00.000Z | medium | 1 | 0 | task | 1 |
| 29 | Website and social | 2026-10-09T00:00:00.000Z | 2026-10-30T00:00:00.000Z | medium | 1 | 0 | task | 1 |
| 30 | Local press outreach | 2026-10-29T00:00:00.000Z | 2026-11-12T00:00:00.000Z | medium | 1 | 0 | task | 1 |
| 31 | Soft launch | 2026-11-18T00:00:00.000Z | 2026-11-22T00:00:00.000Z | medium | 1 | 0 | milestone | 1 |
| 32 | Grand opening | 2026-11-26T00:00:00.000Z | 2026-11-27T00:00:00.000Z | high | 1 | 0 | milestone | 1 |
